# Paatti-projekti

Schedule from GanttProject, 2012-01-23 to 2012-05-18.
Jyväskylän yliopiston tietotekniikan laitos

## Calendars

- Project calendar: Mon-Fri working; Sat-Sun off.

## Resources

| Resource |
| --- |
| Toni Salminen |
| Tapio Keränen |
| Jari Salokangas |
| Lauri Satokangas |

## Schedule

| ID | WBS | Task | Type | Duration | Start | Finish | Predecessors | Resources |
| --- | --- | --- | --- | --- | --- | --- | --- | --- |
| 1 | 1 | **Projektin hallinta** |  | 85d | 2012-01-23 | 2012-05-18 |  |  |
| 2 | 1.1 | Projektin suunnittelu |  | 50d | 2012-01-23 | 2012-03-30 |  |  |
| 3 | 1.2 | Projektipäällikkö vaihtuu | milestone | 0d | 2012-04-09 | 2012-04-09 |  | Lauri Satokangas |
| 4 | 1.3 | Projektin raportointi |  | 19d | 2012-04-17 | 2012-05-11 | 2 |  |
| 5 | 1.4 | Tulosten viimeistely |  | 5d | 2012-05-07 | 2012-05-11 |  |  |
| 6 | 1.5 | Tulosten luovutus |  | 5d | 2012-05-14 | 2012-05-18 | 5, 43, 44 |  |
| 7 | 2 | **Perehtyminen** |  | 70d | 2012-01-23 | 2012-04-27 |  |  |
| 8 | 2.1 | Aihealue |  | 50d | 2012-01-23 | 2012-03-30 |  | Toni Salminen [10%]; Jari Salokangas [10%]; Lauri Satokangas [10%] |
| 9 | 2.2 | Sovelluskehittimet |  | 62d | 2012-02-02 | 2012-04-27 |  |  |
| 10 | 3 | **Määrittely** |  | 42d | 2012-02-02 | 2012-03-30 |  | Toni Salminen [20%]; Tapio Keränen [50%]; Jari Salokangas [20%]; Lauri Satokangas [20%] |
| 11 | 3.1 | Vaatimusmäärittely |  | 42d | 2012-02-02 | 2012-03-30 |  | Toni Salminen [20%]; Tapio Keränen [50%]; Jari Salokangas [20%]; Lauri Satokangas [20%] |
| 12 | 4 | **Suunnittelu** |  | 47d | 2012-02-02 | 2012-04-06 |  |  |
| 13 | 4.1 | Sisäänkirjautuminen |  | 3d | 2012-03-26 | 2012-03-28 |  |  |
| 14 | 4.2 | Käyttäjäroolit |  | 15d | 2012-03-05 | 2012-03-23 |  |  |
| 15 | 4.3 | Tietokanta |  | 19d | 2012-02-28 | 2012-03-23 |  | Tapio Keränen [30%] |
| 16 | 4.4 | **Kuntoutettavan käyttöliittymä** |  | 32d | 2012-02-02 | 2012-03-16 |  |  |
| 17 | 4.4.1 | Rakenne |  | 22d | 2012-02-02 | 2012-03-02 |  |  |
| 18 | 4.4.2 | Näkymät |  | 25d | 2012-02-06 | 2012-03-09 |  |  |
| 19 | 4.4.3 | Ulkoasu |  | 32d | 2012-02-02 | 2012-03-16 |  |  |
| 20 | 4.5 | **Tutkijan käyttöliittymä** |  | 45d | 2012-02-06 | 2012-04-06 |  |  |
| 21 | 4.5.1 | Rakenne |  | 15d | 2012-03-19 | 2012-04-06 |  |  |
| 22 | 4.5.2 | Tapahtumamuokkain |  | 35d | 2012-02-06 | 2012-03-23 |  |  |
| 23 | 4.5.3 | Aikataulutus |  | 20d | 2012-03-05 | 2012-03-30 |  |  |
| 24 | 4.5.4 | Hallintatyökalut |  | 5d | 2012-03-26 | 2012-03-30 |  |  |
| 25 | 4.5.5 | Ulkoasu |  | 20d | 2012-03-12 | 2012-04-06 |  |  |

| ID | WBS | Task | Duration | Start | Finish | Resources |
| --- | --- | --- | --- | --- | --- | --- |
| 26 | 5 | **Toteutus** | 44d | 2012-03-06 | 2012-05-04 |  |
| 27 | 5.1 | Sisäänkirjautuminen | 3d | 2012-03-29 | 2012-04-02 |  |
| 28 | 5.2 | Tietokanta | 10d | 2012-03-19 | 2012-03-30 |  |
| 29 | 5.3 | **Kuntoutettavan käyttöliittymä** | 34d | 2012-03-06 | 2012-04-20 | Lauri Satokangas [70%] |
| 30 | 5.3.1 | Rakenne | 14d | 2012-03-06 | 2012-03-23 |  |
| 31 | 5.3.2 | Näkymät | 25d | 2012-03-19 | 2012-04-20 |  |
| 32 | 5.3.3 | Ulkoasu | 10d | 2012-04-09 | 2012-04-20 |  |
| 33 | 5.4 | **Tutkijan käyttöliittymä** | 40d | 2012-03-12 | 2012-05-04 |  |
| 34 | 5.4.1 | Rakenne | 10d | 2012-03-26 | 2012-04-06 |  |
| 35 | 5.4.2 | Tapahtumamuokkain | 25d | 2012-03-12 | 2012-04-13 |  |
| 36 | 5.4.3 | Aikataulutus | 20d | 2012-04-02 | 2012-04-27 |  |
| 37 | 5.4.4 | Hallintatyökalut | 20d | 2012-04-02 | 2012-04-27 |  |
| 38 | 5.4.5 | Ulkoasu | 15d | 2012-04-16 | 2012-05-04 |  |
| 39 | 6 | **Testaus** | 10d | 2012-04-23 | 2012-05-04 |  |
| 40 | 6.1 | Järjestelmätestaus | 10d | 2012-04-23 | 2012-05-04 |  |
| 41 | 6.2 | Käytettävyystestaus | 10d | 2012-04-23 | 2012-05-04 |  |
| 42 | 7 | **Viimeistely** | 10d | 2012-04-30 | 2012-05-11 |  |
| 43 | 7.1 | Sovelluksen viimeistely | 10d | 2012-04-30 | 2012-05-11 |  |
| 44 | 7.2 | Sovellusraportti | 10d | 2012-04-30 | 2012-05-11 | Jari Salokangas [50%] |
